# Target Hall shedule 130 Apr to Sep

Schedule from MS Project, 2016-04-25 to 2016-09-05, A marks actual dates.

## Calendars

- Standard: Mon-Fri 08:00-12:00, 13:00-17:00; Sat-Sun off.

## Resources

| Resource |
| --- |
| Wang.D |
| Cave.T |
| Fisher.C |
| Mjos.A |
| RPG |
| Target group |
| Mcdonald.D |

## Schedule

| ID | WBS | Task | Duration | Start | Finish | Predecessors | Complete | Remaining | Total slack | Constraint | Resources | Work | Actual work |
| --- | --- | --- | --- | --- | --- | --- | --- | --- | --- | --- | --- | --- | --- |
| 1 | 1 | **TM2 LpTa Ready for ITW** | 30d | 2016-04-25 08:00 A | 2016-06-03 17:00 A |  | 100% |  |  |  |  | 275.04h | 275.04h |
| 2 | 1.1 | TM2 Leak Check -TCS | 5d | 2016-04-25 08:00 A | 2016-04-29 17:00 A |  | 100% |  |  | start no earlier than 2016-04-25 08:00 | Mjos.A; Wang.D | 80h | 80h |
| 3 | 1.2 | Module Move-TM2-TCS to silo | 0.5d | 2016-05-02 08:00 A | 2016-05-02 12:00 A |  | 100% |  |  | start no earlier than 2016-05-02 08:00 | Cave.T; Wang.D | 8h | 8h |
| 4 | 1.3 | Module Move-TM3-Silo to TCS | 0.5d | 2016-05-02 13:00 A | 2016-05-02 17:00 A | 3 | 100% |  |  | finish no earlier than 2016-05-02 17:00 | Cave.T; Wang.D | 8h | 8h |
| 5 | 1.4 | TM3 Inspection-TCS | 3d | 2016-05-03 08:00 A | 2016-05-05 17:00 A | 4 | 100% |  |  | start no earlier than 2016-05-03 08:00 | Target group; Mcdonald.D | 48h | 48h |
| 6 | 1.5 | Shielding Block transfer-ITW to ITE | 1d | 2016-05-06 08:00 A | 2016-05-06 17:00 A |  | 100% |  |  | start no earlier than 2016-05-06 08:00 | Wang.D | 8h | 8h |
| 7 | 1.6 | Module Move-TM3-TCS to Silo | 0.5d | 2016-05-09 08:00 A | 2016-05-09 12:00 A | 5 | 100% |  |  | start no earlier than 2016-05-09 08:00 | Cave.T; Wang.D | 8h | 8h |
| 8 | 1.7 | Moduel Move-TM2 Silo to SHC | 0.5d | 2016-05-09 13:00 A | 2016-05-09 17:00 A | 7 | 100% |  |  | start no earlier than 2016-05-09 08:00 | Cave.T; Wang.D | 8h | 8h |
| 9 | 1.8 | Window Line Gaskets installation-TM2 -SHC | 1d | 2016-05-10 08:00 A | 2016-05-10 17:00 A |  | 100% |  |  | start no earlier than 2016-05-10 08:00 | Fisher.C | 8h | 8h |
| 10 | 1.9 | Lp Ta Target Insert -SHC | 0.5d | 2016-05-12 08:00 A | 2016-05-12 12:00 A | 9 | 100% |  |  | start no earlier than 2016-05-12 08:00 | Fisher.C; Mjos.A | 8h | 8h |
| 11 | 1.10 | Target Installation/Electrical Check | 0.5d | 2016-05-12 13:00 A | 2016-05-12 17:00 A | 10 | 100% |  |  | start no earlier than 2016-05-11 08:00 | Cave.T; Fisher.C; Wang.D | 12h | 12h |
| 12 | 1.11 | Moudle Move-TM2-SHC to TCS | 0.5d | 2016-05-13 08:00 A | 2016-05-13 12:00 A | 11 | 100% |  |  | start no earlier than 2016-05-12 08:00 | Cave.T; Wang.D | 8h | 8h |
| 13 | 1.12 | Module Connection-TM2-TSC/Start of Pumps | 0.5d | 2016-05-13 13:00 A | 2016-05-13 17:00 A | 12 | 100% |  |  | start no earlier than 2016-05-12 08:00 | Wang.D | 4h | 4h |
| 14 | 1.13 | Camera Setting up-ITW | 0.13d | 2016-05-17 08:00 A | 2016-05-17 09:02 A | 13 | 100% |  |  | start no earlier than 2016-05-17 08:00 | Cave.T | 1.04h | 1.04h |
| 15 | 1.14 | Module Disconnection-TM1-ITW | 0.37d | 2016-05-17 09:02 A | 2016-05-17 12:00 A | 14 | 100% |  |  | start no earlier than 2016-05-17 08:00 | Wang.D | 2.96h | 2.96h |
| 16 | 1.15 | Module Move -TM1-SHC | 0.25d | 2016-05-17 13:00 A | 2016-05-17 15:00 A | 15 | 100% |  |  | start no earlier than 2016-05-17 08:00 | Cave.T; Wang.D | 4h | 4h |
| 17 | 1.16 | Target Remove-TM1-SHC | 0.13d | 2016-05-17 15:00 A | 2016-05-17 16:02 A | 16 | 100% |  |  | start no earlier than 2016-05-17 08:00 | Fisher.C | 1.04h | 1.04h |
| 18 | 1.17 | Module Move-TM1-SHC to Silo | 1d | 2016-05-18 08:00 A | 2016-05-18 17:00 A | 17 | 100% |  |  | start no earlier than 2016-05-18 08:00 | Cave.T; Wang.D | 16h | 16h |
| 19 | 1.18 | Spent Target Move | 1d | 2016-06-03 08:00 A | 2016-06-03 17:00 A | 18 | 100% |  |  | start no earlier than 2016-06-03 08:00 | Cave.T; Fisher.C; Wang.D | 24h | 24h |
| 20 | 1.19 | Module Disconnection-TM2-TCS | 0.25d | 2016-05-25 08:00 A | 2016-05-25 10:00 A |  | 100% |  |  | start no earlier than 2016-05-25 08:00 | Wang.D | 2h | 2h |
| 21 | 1.20 | Module Move -TM2-ITW | 0.25d | 2016-05-25 10:00 A | 2016-05-25 12:00 A | 20 | 100% |  |  | start no earlier than 2016-05-25 08:00 | Cave.T; Wang.D | 4h | 4h |
| 22 | 1.21 | Module Connection- TM2-ITW/ Start of Pumps | 0.5d | 2016-05-25 13:00 A | 2016-05-25 17:00 A | 21 | 100% |  |  | start no earlier than 2016-05-25 08:00 | Wang.D | 4h | 4h |
| 23 | 1.22 | Shielding Blocks Transfer-ITE to ITW | 1d | 2016-05-30 08:00 A | 2016-05-30 17:00 A | 22 | 100% |  |  | start no earlier than 2016-05-30 08:00 | Wang.D | 8h | 8h |
| 24 | 2 | **TM4 LP Ucx Ready for ITE** | 15d | 2016-06-07 08:00 A | 2016-06-27 17:00 |  | 75% | 3.75d | 50d |  |  | 55.2h | 47.2h |
| 25 | 2.1 | LpUCx target Insert to SHC | 0.1d | 2016-06-07 08:00 A | 2016-06-07 08:48 A |  | 100% |  |  | start no earlier than 2016-06-07 08:00 | Fisher.C; Mjos.A | 1.6h | 1.6h |
| 26 | 2.2 | Module Disconnection-TM4 -ITE | 0.2d | 2016-06-07 15:24 A | 2016-06-07 17:00 A | 25 | 100% |  |  | finish no earlier than 2016-06-07 17:00 | Wang.D | 1.6h | 1.6h |
| 27 | 2.3 | Module Move-TM4-ITE to SHC | 0.2d | 2016-06-07 08:00 A | 2016-06-07 09:36 A |  | 100% |  |  | start no earlier than 2016-06-07 08:00 | Cave.T; Wang.D | 3.2h | 3.2h |
| 28 | 2.4 | LpUCx Installation/Electrical Check | 0.1d | 2016-06-07 09:36 A | 2016-06-07 10:24 A | 27 | 100% |  |  | start no earlier than 2016-06-07 08:00 | Cave.T; Fisher.C; Wang.D | 2.4h | 2.4h |
| 29 | 2.5 | Module Move-TM4-SHC to TCS | 0.2d | 2016-06-07 10:24 A | 2016-06-07 12:00 A | 28 | 100% |  |  | start no earlier than 2016-06-07 08:00 | Cave.T; Wang.D | 3.2h | 3.2h |
| 30 | 2.6 | Module Connection-TM4-TCS/Start of Pumps | 0.2d | 2016-06-07 13:00 A | 2016-06-07 14:36 A | 29 | 100% |  |  | start no earlier than 2016-06-07 08:00 | Wang.D | 1.6h | 1.6h |
| 31 | 2.7 | Spent Targt Move | 1d | 2016-06-16 08:00 A | 2016-06-16 17:00 A | 30 | 100% |  |  | start no earlier than 2016-06-16 08:00 | Cave.T; Fisher.C; Wang.D | 24h | 24h |
| 32 | 2.8 | Module Disconnection-TM4 -TCS | 0.2d | 2016-06-14 08:00 A | 2016-06-14 09:36 A | 30 | 100% |  |  | start no earlier than 2016-06-14 08:00 | Wang.D | 1.6h | 1.6h |
| 33 | 2.9 | Module Move-TM4-TSC to ITE | 0.2d | 2016-06-14 09:36 A | 2016-06-14 11:12 A | 32 | 100% |  |  | start no earlier than 2016-06-14 08:00 | Cave.T; Wang.D | 3.2h | 3.2h |
| 34 | 2.10 | Module connection-TM4-ITE/Start of Pumps | 0.6d | 2016-06-14 11:12 A | 2016-06-14 17:00 A | 33 | 100% |  |  | start no earlier than 2016-06-14 08:00 | Wang.D | 4.8h | 4.8h |
| 35 | 2.11 | shielding Blocks Transfer ITW to ITE | 1d | 2016-06-27 08:00 | 2016-06-27 17:00 | 34 |  |  | 52d | start no earlier than 2016-06-27 08:00 | Wang.D | 8h |  |

| ID | WBS | Task | Duration | Start | Finish | Predecessors | Complete | Remaining | Total slack | Free slack | Constraint | Resources | Work | Actual work |
| --- | --- | --- | --- | --- | --- | --- | --- | --- | --- | --- | --- | --- | --- | --- |
| 36 | 3 | **TM2 HpSiC Ready for ITW** | 10d | 2016-07-05 08:00 A | 2016-07-18 17:00 |  | 76% | 2.35d | 34.9d |  |  |  | 64h | 56h |
| 37 | 3.1 | HpSiC Target Insert into SHC | 0.25d | 2016-07-05 08:00 A | 2016-07-05 10:00 A | 35 | 100% |  |  |  | start no earlier than 2016-07-05 08:00 | Cave.T; Mjos.A | 4h | 4h |
| 38 | 3.2 | Camera Setting up-ITW | 0.25d | 2016-07-05 10:00 A | 2016-07-05 12:00 A | 37 | 100% |  |  |  | start no earlier than 2016-07-05 08:00 | Cave.T | 2h | 2h |
| 39 | 3.3 | Module Move_TM2-ITW to SHC | 0.25d | 2016-07-05 15:00 A | 2016-07-05 17:00 A | 38 | 100% |  |  |  | finish no earlier than 2016-07-05 17:00 | Cave.T; Wang.D | 4h | 4h |
| 40 | 3.4 | HpSiC Target Installation/Electrical Check | 0.4d | 2016-07-06 08:00 A | 2016-07-06 11:12 A | 39 | 100% |  |  |  | start no earlier than 2016-07-05 08:00 | Cave.T; Fisher.C; Wang.D | 9.6h | 9.6h |
| 41 | 3.5 | Module Move-TM2-SHC to TCS | 0.25d | 2016-07-06 11:12 A | 2016-07-06 14:12 A | 40 | 100% |  |  |  | start no earlier than 2016-07-06 08:00 | Cave.T; Wang.D | 4h | 4h |
| 42 | 3.6 | Module Connection-TM2-TSC/Start of Pumps | 0.25d | 2016-07-06 14:12 A | 2016-07-06 16:12 A | 41 | 100% |  |  |  | start no earlier than 2016-07-06 08:00 | Wang.D | 2h | 2h |
| 43 | 3.7 | Spent Target Move | 1d | 2016-07-07 08:00 A | 2016-07-07 17:00 A | 42 | 100% |  |  |  | start no earlier than 2016-07-07 08:00 | Cave.T; Fisher.C; Wang.D | 24h | 24h |
| 44 | 3.8 | Module Disconnetion-TM2-TCS | 0.2d | 2016-07-12 08:00 A | 2016-07-12 09:36 A | 43 | 100% |  |  |  | start no earlier than 2016-07-12 08:00 | Wang.D | 1.6h | 1.6h |
| 45 | 3.9 | Module Move-TM2-TCS to ITW | 0.2d | 2016-07-12 15:24 A | 2016-07-12 17:00 A | 44 | 100% |  |  |  | finish no earlier than 2016-07-12 17:00 | Cave.T; Wang.D | 3.2h | 3.2h |
| 46 | 3.10 | Module Connection-TM2-ITW/Start of Pumps | 0.2d | 2016-07-12 15:24 A | 2016-07-12 17:00 A |  | 100% |  |  |  | finish no earlier than 2016-07-12 17:00 | Wang.D | 1.6h | 1.6h |
| 47 | 3.11 | Shielding Blocks Transfer-ITE to ITW | 1d | 2016-07-18 08:00 | 2016-07-18 17:00 | 46 |  |  | 34.9d | 10.9d | start no earlier than 2016-07-18 08:00 | Wang.D | 8h |  |
| 48 | 4 | **TM4 LP Ucx Ready for ITE** | 10d | 2016-08-02 08:00 | 2016-08-15 17:00 |  |  |  | 15d |  |  |  | 53.6h |  |
| 49 | 4.1 | Lp Ucx target Insert into SHC | 0.1d | 2016-08-02 16:12 | 2016-08-02 17:00 | 47 |  |  | 24d |  | finish no earlier than 2016-08-02 17:00 | Fisher.C; Mjos.A | 1.6h |  |
| 50 | 4.2 | Module Disconnection TM4-ITE | 0.2d | 2016-08-02 08:00 | 2016-08-02 09:36 |  |  |  | 26.6d | 0.6d | start no earlier than 2016-08-02 08:00 | Wang.D | 1.6h |  |
| 51 | 4.3 | Module Move-TM4-ITE to SHC | 0.2d | 2016-08-02 15:24 | 2016-08-02 17:00 | 50 |  |  | 24d |  | finish no earlier than 2016-08-02 17:00 | Cave.T; Wang.D | 3.2h |  |
| 52 | 4.4 | UCx Target Installation/Electrical check-SHC | 0.2d | 2016-08-02 08:00 | 2016-08-02 09:36 |  |  |  | 21.8d | 0d | start no earlier than 2016-08-02 08:00 | Cave.T; Fisher.C; Wang.D | 4.8h |  |
| 53 | 4.5 | Module Move-TM4-SHC to TCS | 0.1d | 2016-08-02 09:36 | 2016-08-02 10:24 | 52 |  |  | 21.8d | 0d | start no earlier than 2016-08-02 08:00 | Cave.T; Wang.D | 1.6h |  |
| 54 | 4.6 | Module Connection-TM4-TCS/Start of Pumps | 0.1d | 2016-08-02 10:24 | 2016-08-02 11:12 | 53 |  |  | 21.8d | 1.6d | start no earlier than 2016-08-02 08:00 | Wang.D | 0.8h |  |
| 55 | 4.7 | Spent Target Move | 1d | 2016-08-04 08:00 | 2016-08-04 17:00 | 54 |  |  | 20.2d | 2d | start no earlier than 2016-08-04 08:00 | Cave.T; Fisher.C; Wang.D | 24h |  |
| 56 | 4.8 | Module Disconnection-TM4-TSC | 0.1d | 2016-08-09 08:00 | 2016-08-09 08:48 | 55 |  |  | 18.2d | 0d | start no earlier than 2016-08-09 08:00 | Wang.D | 0.8h |  |
| 57 | 4.9 | Module Move-TM4-TCS to ITE | 0.2d | 2016-08-09 08:48 | 2016-08-09 10:24 | 56 |  |  | 18.2d | 0d | start no earlier than 2016-08-09 08:00 | Cave.T; Wang.D | 3.2h |  |
| 58 | 4.10 | Module Connection-TM4-ITE/Start of Pumps | 0.5d | 2016-08-09 10:24 | 2016-08-09 15:24 | 57 |  |  | 13.45d | 3.2d | start no earlier than 2016-08-09 08:00 | Wang.D | 4h |  |
| 59 | 4.11 | shielding Blocks Move | 1d | 2016-08-15 08:00 | 2016-08-15 17:00 | 58 |  |  | 15d |  | start no earlier than 2016-08-15 08:00 | Wang.D | 8h |  |

| ID | WBS | Task | Duration | Start | Finish | Predecessors | Total slack | Free slack | Constraint | Resources | Work |
| --- | --- | --- | --- | --- | --- | --- | --- | --- | --- | --- | --- |
| 60 | 5 | **TM2 Ready for ITE** | 10d? | 2016-08-23 08:00 | 2016-09-05 17:00 |  | 0d |  |  |  | 88h |
| 61 | 5.1 | New Target to SHC | 0.25d | 2016-08-23 08:00 | 2016-08-23 10:00 | 59 | 5.25d | 0d | start no earlier than 2016-08-23 08:00 | Fisher.C; Mjos.A | 4h |
| 62 | 5.2 | Module Disconnection-TM2-ITW | 0.25d | 2016-08-23 10:00 | 2016-08-23 12:00 | 61 | 5.25d | 0d | start no earlier than 2016-08-23 08:00 | Wang.D; Mcdonald.D | 4h |
| 63 | 5.3 | Module Move-TM2-ITW to SHC | 0.25d | 2016-08-23 13:00 | 2016-08-23 15:00 | 62 | 5.25d | 0.25d | start no earlier than 2016-08-23 08:00 | Cave.T; Wang.D | 4h |
| 64 | 5.4 | New Target Installation/Electrical Check | 0.5d | 2016-08-24 08:00 | 2016-08-24 12:00 | 63 | 5d | 0d | start no earlier than 2016-08-24 08:00 | Cave.T; Fisher.C; Wang.D | 12h |
| 65 | 5.5 | Module Move-TM2-SHC to CS/Start of Pumps | 0.5d | 2016-08-24 13:00 | 2016-08-24 17:00 | 64 | 5d | 0d | start no earlier than 2016-08-24 08:00 | Wang.D | 4h |
| 66 | 5.6 | Spent Target Move | 1d? | 2016-08-25 08:00 | 2016-08-25 17:00 | 65 | 5d | 2d | start no earlier than 2016-08-25 08:00 | Cave.T; Wang.D; Fisher.C | 24h |
| 67 | 5.7 | Module Move-TM2-TCS to ITW | 0.5d | 2016-08-30 08:00 | 2016-08-30 12:00 | 66 | 3d | 0d | start no earlier than 2016-08-30 08:00 | Cave.T; Mcdonald.D; Wang.D | 12h |
| 68 | 5.8 | Module Connection-TM2-ITW/Start of Pumps | 0.5d | 2016-08-30 13:00 | 2016-08-30 17:00 | 67 | 3d |  | start no earlier than 2016-08-30 08:00 | Mcdonald.D; Wang.D | 8h |
| 69 | 5.9 | Shielding Blocks Transfer-ITE to ITW | 1d | 2016-09-05 08:00 | 2016-09-05 17:00 | 68 | 0d |  | start no earlier than 2016-09-05 08:00 | Mcdonald.D; Wang.D | 16h |
